# K55_átadás_átvétel_birtokbaadás ütemterve

Schedule from MS Project, 2021-09-10 to 2021-10-21.

## Calendars

- Szabványos: Mon-Fri 08:00-12:00, 13:00-17:00; Sat-Sun off. Exceptions (off unless hours are given): 2021-09-01 to 2022-02-16 08:00-12:00, 13:00-17:00 (k55).

## Schedule

| ID | WBS | Task | Duration | Start | Finish | Predecessors | Total slack | Free slack | Constraint |
| --- | --- | --- | --- | --- | --- | --- | --- | --- | --- |
| 1 | 1 | **Projekt Név - Átadás/átvétel, birtokbaadás ütemterve** | 42d | 2021-09-10 | 2021-10-21 |  | 0d |  |  |
| 3 | 1.1 | **B, C, D tömb** | 24d | 2021-09-10 | 2021-10-03 |  | 18d |  |  |
| 4 | 1.1.1 | Piperetakarítás | 3d | 2021-09-11 | 2021-09-13 |  | 38d |  | start no earlier than 2021-09-11 |
| 5 | 1.1.2 | Tárgyi terület kulcsainak átadása | 1d | 2021-09-13 | 2021-09-13 |  | 18d | 0d | start no earlier than 2021-09-13 |
| 6 | 1.1.3 | Bútorok átadása | 2d | 2021-09-14 | 2021-09-15 | 5 | 18d | 0d | finish no earlier than 2021-09-15 |
| 7 | 1.1.4 | Projekt Név 2 - munkaállomások telepítése | 18d | 2021-09-16 | 2021-10-03 | 6 | 18d |  | finish no earlier than 2021-10-03 |
| 9 | 1.1.5 | **Fitout terület:** | 23d | 2021-09-10 | 2021-10-02 |  | 19d |  |  |
| 10 | 1.1.5.1 | Kivitelezés | 18d | 2021-09-10 | 2021-09-27 |  | 19d | 0d | start no earlier than 2021-09-10 |
| 11 | 1.1.5.2 | Piperetakarítás | 1d | 2021-09-28 | 2021-09-28 | 10, 25 | 19d | 0d | finish no earlier than 2021-09-28 |
| 12 | 1.1.5.3 | Tárgyi terület kulcsainak átadása | 1d | 2021-09-29 | 2021-09-29 | 11, 19 | 22d |  | finish no earlier than 2021-09-29 |
| 13 | 1.1.5.4 | Bútorok átadása | 1d | 2021-09-29 | 2021-09-29 | 11, 19 | 19d | 0d | finish no earlier than 2021-09-29 |
| 14 | 1.1.5.5 | Projekt Név 2 - munkaállomások telepítése | 3d | 2021-09-30 | 2021-10-02 | 13 | 19d |  | finish no earlier than 2021-10-02 |
| 16 | 1.2 | **A tömb** | 41d | 2021-09-10 | 2021-10-20 |  | 1d |  |  |
| 17 | 1.2.1 | **3., 4., 5. emelet** | 21d | 2021-09-10 | 2021-09-30 |  | 21d |  |  |
| 18 | 1.2.1.1 | Kivitelezés | 8d | 2021-09-10 | 2021-09-17 |  | 21d | 0d | start no earlier than 2021-09-10 |
| 19 | 1.2.1.2 | Piperetakarítás | 2d | 2021-09-18 | 2021-09-19 | 18 | 21d | 0d | finish no earlier than 2021-09-19 |
| 20 | 1.2.1.3 | Tárgyi terület kulcsainak átadása | 1d | 2021-09-20 | 2021-09-20 | 19 | 31d |  | finish no earlier than 2021-09-20 |
| 21 | 1.2.1.4 | Bútorok átadása | 1d | 2021-09-20 | 2021-09-20 | 19 | 21d | 0d | finish no earlier than 2021-09-20 |
| 22 | 1.2.1.5 | Projekt Név 2 - munkaállomások telepítése | 10d | 2021-09-21 | 2021-09-30 | 21 | 21d |  | finish no earlier than 2021-09-30 |
| 24 | 1.2.2 | **1., 2. emelet** | 24d | 2021-09-10 | 2021-10-03 |  | 18d |  |  |
| 25 | 1.2.2.1 | Kivitelezés | 15d | 2021-09-10 | 2021-09-24 |  | 18d | 0d | start no earlier than 2021-09-10 |
| 26 | 1.2.2.2 | Piperetakarítás | 2d | 2021-09-25 | 2021-09-26 | 25 | 18d | 0d | finish no earlier than 2021-09-26 |
| 27 | 1.2.2.3 | Tárgyi terület kulcsainak átadása | 1d | 2021-09-27 | 2021-09-27 | 26 | 24d |  | finish no earlier than 2021-09-27 |
| 28 | 1.2.2.4 | Bútorok átadása | 1d | 2021-09-27 | 2021-09-27 | 26 | 18d | 0d | finish no earlier than 2021-09-27 |
| 29 | 1.2.2.5 | Projekt Név 2 - munkaállomások telepítése | 6d | 2021-09-28 | 2021-10-03 | 28 | 18d |  | finish no earlier than 2021-10-03 |

| ID | WBS | Task | Duration | Start | Finish | Predecessors | Total slack | Free slack | Constraint |
| --- | --- | --- | --- | --- | --- | --- | --- | --- | --- |
| 31 | 1.2.3 | **földszint + lift és lift melletti lépcsőház** | 41d | 2021-09-10 | 2021-10-20 |  | 1d |  |  |
| 32 | 1.2.3.1 | Kivitelezés | 37d | 2021-09-10 | 2021-10-16 |  | 1d | 0d | start no earlier than 2021-09-10 |
| 33 | 1.2.3.2 | Piperetakarítás | 1d | 2021-10-17 | 2021-10-17 | 32 | 1d | 0d | finish no earlier than 2021-10-17 |
| 34 | 1.2.3.3 | Bútorok átadása | 1d | 2021-10-18 | 2021-10-18 | 33 | 1d | 0d | finish no earlier than 2021-10-18 |
| 35 | 1.2.3.4 | Tárgyi terület kulcsainak átadása | 1d | 2021-10-19 | 2021-10-19 | 34 | 2d |  | finish no earlier than 2021-10-18 |
| 36 | 1.2.3.5 | Projekt Név 2 - munkaállomások telepítése | 2d | 2021-10-19 | 2021-10-20 | 34 | 1d |  | finish no earlier than 2021-10-20 |
| 38 | 1.3 | Műszaki átadás/átvétel (A, B, C, D tömbök; Aula; Kávézó; Mélygarázs) | 9d | 2021-09-20 | 2021-09-28 |  | 18d | 0d | start no earlier than 2021-09-20 |
| 39 | 1.4 | Birtokbavétel (A, B, C, D tömbök; Aula; Mélygarázs) | 1d | 2021-09-29 | 2021-09-29 | 38 | 18d | 0d | finish no earlier than 2021-09-29 |
| 40 | 1.5 | Költözés előtti takarítás (üzemeltetés által) | 4d | 2021-09-30 | 2021-10-03 | 39 | 18d |  | start no earlier than 2021-09-30 |
| 42 | 1.6 | Tűzoltósági bejárás | 1d | 2021-09-24 | 2021-09-24 |  | 27d |  | start no earlier than 2021-09-24 |
| 43 | 1.7 | Tűzjelző hatósági engedélyének kiadása | 1d | 2021-09-27 | 2021-09-27 |  | 24d |  | start no earlier than 2021-09-27 |
| 44 | 1.8 | X osztály beköltözése | 1d | 2021-09-29 | 2021-09-29 |  | 22d |  | start no earlier than 2021-09-29 |
| 45 | 1.9 | Üzemeltetés megkezdése | 1d | 2021-09-29 | 2021-09-29 |  | 22d |  | start no earlier than 2021-09-29 |
| 47 | 1.10 | **Egyéb területek** | 41d | 2021-09-10 | 2021-10-20 |  | 1d |  |  |
| 48 | 1.10.1 | Kivitelezés | 37d | 2021-09-10 | 2021-10-16 |  | 1d | 0d | start no earlier than 2021-09-10 |
| 49 | 1.10.2 | Piperetakarítás | 1d | 2021-10-17 | 2021-10-17 | 48 | 1d | 0d | finish no earlier than 2021-10-17 |
| 50 | 1.10.3 | Tárgyi terület kulcsainak átadása | 1d | 2021-10-18 | 2021-10-18 | 49 | 3d |  | finish no earlier than 2021-10-18 |
| 51 | 1.10.4 | Bútorok átadása | 1d | 2021-10-18 | 2021-10-18 | 49 | 1d | 0d | finish no earlier than 2021-10-18 |
| 52 | 1.10.5 | Projekt Név 2 - munkaállomások telepítése | 2d | 2021-10-19 | 2021-10-20 | 51 | 1d |  | finish no earlier than 2021-10-20 |
| 54 | 1.11 | Műszaki átadás/átvétel Egyéb területek | 10d | 2021-10-11 | 2021-10-20 |  | 0d |  | start no earlier than 2021-10-11 |
| 55 | 1.12 | Birtokbavétel Egyéb területek | 1d | 2021-10-21 | 2021-10-21 | 54 | 0d |  | finish no earlier than 2021-10-21 |
| 57 | 1.13 | **Energiaközpont; Főelosztó helyiség** | 26d | 2021-09-20 | 2021-10-15 |  | 6d |  |  |
| 58 | 1.13.1 | Műszaki átadás/átvétel | 5d | 2021-10-11 | 2021-10-15 |  | 6d |  | start no earlier than 2021-10-11 |
| 59 | 1.13.2 | Birtokbavétel | 1d | 2021-09-20 | 2021-09-20 |  | 31d |  | start no earlier than 2021-09-20 |

| ID | WBS | Task | Duration | Start | Finish | Predecessors | Total slack | Free slack | Constraint |
| --- | --- | --- | --- | --- | --- | --- | --- | --- | --- |
| 61 | 1.14 | **Konyha** | 25d | 2021-09-10 | 2021-10-04 |  | 17d |  |  |
| 62 | 1.14.1 | Kivitelezés | 18d | 2021-09-10 | 2021-09-27 |  | 21d | 0d | start no earlier than 2021-09-10 |
| 63 | 1.14.2 | Piperetakarítás | 2d | 2021-09-28 | 2021-09-29 | 62 | 21d | 1d |  |
| 64 | 1.14.3 | Műszaki átadás/átvétel | 1d | 2021-10-01 | 2021-10-01 | 63 | 20d |  | finish no earlier than 2021-10-01 |
| 65 | 1.14.4 | Birtokbavétel - Konyha átadása üzemeltetés részére | 1d | 2021-10-04 | 2021-10-04 |  | 17d |  | start no earlier than 2021-10-04 |
| 67 | 1.15 | **Étterem** | 41d | 2021-09-10 | 2021-10-20 |  | 1d |  |  |
| 68 | 1.15.1 | Kivitelezés | 36d | 2021-09-10 | 2021-10-15 |  | 1d | 0d | start no earlier than 2021-09-10 |
| 69 | 1.15.2 | Piperetakarítás | 2d | 2021-10-16 | 2021-10-17 | 68 | 1d | 0d |  |
| 70 | 1.15.3 | Műszaki átadás/átvétel | 1d | 2021-10-18 | 2021-10-18 | 69 | 1d | 0d | finish no earlier than 2021-10-01 |
| 71 | 1.15.4 | Tárgyi terület kulcsainak átadása | 1d | 2021-10-19 | 2021-10-19 | 70 | 1d | 0d | finish no earlier than 2021-09-20 |
| 72 | 1.15.5 | Birtokbavétel | 1d | 2021-10-20 | 2021-10-20 | 71 | 1d |  | start no earlier than 2021-10-04 |
